Schedule from MS Project, 2017-09-14 to 2020-04-03.

## Calendars

- Standardní: Mon-Fri 09:00-13:00, 14:00-18:00; Sat-Sun off.

## Schedule

| ID | WBS | Task | Type | Duration | Start | Finish | Predecessors |
| --- | --- | --- | --- | --- | --- | --- | --- |
| 1 | 1 | SO: Stavební úpravy v areálu národní kulturní památky Kostela sv. Bartoloměje | manual | 130w | 2017-10-02 | 2020-03-27 |  |
| 2 | 2 | STAVBA: | manual | 1d? | 2017-09-14 | 2017-09-14 |  |
| 4 | 3 | Stavebně-historický průzkum | manual | 130w | 2017-10-02 | 2020-03-27 |  |
| 6 | 4 | 1_SO-01: Zvonice | manual | 1d | 2017-09-14 | 2017-09-14 |  |
| 7 | 5 | Zemní práce | manual | 1w | 2017-10-02 | 2017-10-06 |  |
| 8 | 6 | Bourané konstrukce | manual | 2w | 2017-10-09 | 2017-10-20 | 7 |
| 9 | 7 | Nové konstrukce | manual | 4w | 2017-11-06 | 2017-12-01 | 10 |
| 10 | 8 | Sanace | manual | 2w | 2017-10-23 | 2017-11-03 | 8 |
| 11 | 9 | Restaurování/repase výplní otvorů | manual | 10w | 2017-10-23 | 2017-12-29 | 8 |
| 12 | 10 | Kamenické prvky | manual | 4w | 2017-12-18 | 2018-01-12 | 14 |
| 13 | 11 | Zámečnické a kovářské prvky | manual | 6w | 2017-12-18 | 2018-01-26 | 14 |
| 14 | 12 | Truhlářské prvky | manual | 2w | 2017-12-04 | 2017-12-15 | 9 |
| 15 | 13 | Klempířské prvky | manual | 1w | 2017-12-18 | 2017-12-22 | 14 |
| 16 | 14 | Odstraňování prvků | manual | 2w | 2017-10-09 | 2017-10-20 | 7 |
| 17 | 15 | Restaurátorské práce | manual | 16w | 2017-10-23 | 2018-02-09 | 8 |
| 18 | 16 | Rekonstrukce elektrorozvodny | manual | 16w | 2018-03-01 | 2018-06-20 |  |
| 19 | 17 | Zařízení silnoproudé elektrotechnicky | manual | 1w | 2018-06-21 | 2018-06-27 | 18 |
| 20 | 18 | Zařízení slaboproudé elektrotechniky | manual | 1w | 2018-06-21 | 2018-06-27 | 18 |
| 22 | 19 | 2_SO-02: Stará škola | manual | 1d | 2017-09-14 | 2017-09-14 |  |
| 23 | 20 | Zemní práce | manual | 1w | 2017-10-03 | 2017-10-09 |  |
| 24 | 21 | Bourané konstrukce | manual | 2w | 2017-10-10 | 2017-10-23 | 23 |
| 25 | 22 | Nové konstrukce | manual | 4w | 2018-07-31 | 2018-08-27 | 26 |
| 26 | 23 | Sanace | manual | 40w | 2017-10-24 | 2018-07-30 | 24 |
| 27 | 24 | Kamenické prvky | manual | 2w | 2018-09-25 | 2018-10-08 | 28 |
| 28 | 25 | Truhlářské prvky | manual | 4w | 2018-08-28 | 2018-09-24 | 25 |
| 29 | 26 | Klempířské prvky | manual | 1w | 2017-12-18 | 2017-12-22 | 14 |
| 30 | 27 | Odstraňování prvků | manual | 1w | 2017-10-10 | 2017-10-16 | 23 |
| 31 | 28 | Restaurování a repase výplní otvorů | manual | 10w | 2017-10-24 | 2018-01-01 | 24 |
| 32 | 29 | Zařízení silnoproudé elektrotechniky | manual | 1w | 2018-06-28 | 2018-07-04 | 20 |
| 33 | 30 | Zařízení slaboproudé elektrotechniky | manual | 1w | 2018-06-28 | 2018-07-04 | 20 |
| 35 | 31 | 3_SO-03: Kostnice | manual | 1d | 2017-09-14 | 2017-09-14 |  |
| 36 | 32 | Bourané konstrukce | manual | 8w | 2018-04-01 | 2018-05-24 |  |
| 37 | 33 | Nové konstrukce | manual | 1w | 2018-08-03 | 2018-08-09 | 38 |
| 38 | 34 | Sanace | manual | 10w | 2018-05-25 | 2018-08-02 | 36 |
| 39 | 35 | Truhlářské prvky | manual | 10w | 2018-08-10 | 2018-10-18 | 37 |
| 40 | 36 | Klempířské prvky | manual | 1w | 2018-10-19 | 2018-10-25 | 39 |
| 41 | 37 | Ostatní prvky | manual | 1w | 2018-10-19 | 2018-10-25 | 39 |
| 42 | 38 | Restaurátorské práce | manual | 96w | 2018-05-25 | 2020-03-26 | 36 |
| 43 | 39 | Ostatní | manual | 96w | 2018-05-25 | 2020-03-26 | 36 |
| 44 | 40 | Zařízení silnoproudé elektrotechniky | manual | 2w | 2018-07-05 | 2018-07-18 | 33 |
| 45 | 41 | Zařízení slaboproudé elektrotechniky | manual | 2w | 2018-07-05 | 2018-07-18 | 33 |
| 47 | 42 | 4_SO-04: Hradební zeď | manual | 1d | 2017-09-14 | 2017-09-14 |  |
| 48 | 43 | Bourané konstrukce | manual | 8w | 2019-04-01 | 2019-05-24 |  |
| 49 | 44 | Sanace | manual | 12w | 2019-05-27 | 2019-08-16 | 48 |
| 50 | 45 | Kamenické prvky | manual | 16w | 2019-08-19 | 2019-12-06 | 49 |
| 51 | 46 | Zámečnické a kovářské prvky | manual | 8w | 2019-12-09 | 2020-01-31 | 50 |
| 52 | 47 | Restaurátorské práce | manual | 16w | 2019-05-27 | 2019-09-13 | 48 |
| 53 | 48 | Ostatní | manual | 12w | 2019-05-27 | 2019-08-16 | 48 |
| 55 | 49 | 5_SO-05: Parter | manual | 1d | 2017-09-14 | 2017-09-14 |  |
| 56 | 50 | Zemní práce | manual | 16w | 2019-04-01 | 2019-07-19 |  |
| 57 | 51 | Bourané konstrukce | manual | 1w | 2019-07-22 | 2019-07-26 | 56 |
| 58 | 52 | Sanace | manual | 16w | 2019-07-29 | 2019-11-15 | 57 |
| 59 | 53 | Dveře | manual | 10w | 2019-07-29 | 2019-10-04 | 57 |
| 60 | 54 | Restaurátorské práce | manual | 20w | 2019-11-18 | 2020-04-03 | 58 |
| 61 | 55 | Ostatní | manual | 20w | 2019-11-18 | 2020-04-03 | 58 |
| 62 | 56 | Vnitroareálové rozvody silnoproudu | manual | 4w | 2019-07-29 | 2019-08-23 | 57 |
| 63 | 57 | Vnitroareálové rozvody slaboroudu | manual | 4w | 2019-07-29 | 2019-08-23 | 57 |
| 64 | 58 | Sadové úpravy | manual | 10w | 2019-09-01 | 2019-11-07 |  |
| 66 | 59 | 6_IO: Inženýrské objekty | manual | 1d | 2017-09-14 | 2017-09-14 |  |
| 67 | 60 | Přípojka vody | manual | 8w | 2019-11-18 | 2020-01-10 | 58 |
| 68 | 61 | Přípojka kanalizace | manual | 8w | 2019-11-18 | 2020-01-10 | 58 |
| 69 | 62 | Přípojka slaboproudu | manual | 8w | 2019-11-18 | 2020-01-10 | 58 |
| 70 | 63 | Nasvětlení vnějších fasád | manual | 2w | 2020-02-01 | 2020-02-13 |  |
| 71 | 64 | Přípojka NN | manual | 8w | 2019-11-18 | 2020-01-10 | 58 |
| 72 | 65 | Veřejné osvětlení | manual | 4w | 2019-11-18 | 2019-12-13 | 58 |
| 74 | 66 | PARKÁN: | manual | 1d? | 2017-09-14 | 2017-09-14 |  |
| 75 | 67 | SO-01 Parkán | manual | 1d? | 2017-09-14 | 2017-09-14 |  |
| 76 | 68 | Terénní úpravy | manual | 2w | 2019-04-01 | 2019-04-12 |  |
| 77 | 69 | Sadební úpravy | manual | 16w | 2019-09-01 | 2019-12-19 |  |
| 78 | 70 | Sanace zdí, zídek a schodišť | manual | 10w | 2019-07-29 | 2019-10-04 | 57 |

| ID | WBS | Task | Type | Duration | Start | Finish | Predecessors |
| --- | --- | --- | --- | --- | --- | --- | --- |
| 79 | 71 | Zahradní domek | manual | 24w | 2019-04-01 | 2019-09-13 |  |
| 80 | 72 | Silnoproud | manual | 2w | 2019-09-16 | 2019-09-27 | 79 |
| 81 | 73 | Slaboproud | manual | 2w | 2019-09-16 | 2019-09-27 | 79 |
| 82 | 74 | Chodníky | manual | 2w | 2019-09-01 | 2019-09-12 |  |
| 84 | 75 | SO-02 Suterén muzea | manual | 1d? | 2017-09-14 | 2017-09-14 |  |
| 85 | 76 | Bourání kci | manual | 2w | 2019-09-13 | 2019-09-26 | 82 |
| 86 | 77 | Sanace kci | manual | 8w | 2019-09-27 | 2019-11-21 | 85 |
| 87 | 78 | Podlahy | manual | 4w | 2019-11-22 | 2019-12-19 | 86 |
| 88 | 79 | Zdravotně technické instalace | manual | 8w | 2019-12-20 | 2020-02-13 | 87 |
| 89 | 80 | Výplně otvorú | manual | 8w | 2019-09-27 | 2019-11-21 | 85 |
| 90 | 81 | Dokončovací práce | manual | 8w | 2020-01-17 | 2020-03-12 | 91 |
| 91 | 82 | Restaurátorské práce | manual | 8w | 2019-11-22 | 2020-01-16 | 86 |
